# iCampus_Comms_Project_10-9

Schedule from MS Project, 2005-10-10 to 2005-12-30.
mit

## Calendars

- Standard: Mon-Fri 08:00-12:00, 13:00-17:00; Sat-Sun off.

## Resources

| Resource |
| --- |
| Marsha |
| M |
| Hecht |
| Bob Wilkes |
| Paul |
| Phil |
| Elisabeth? |
| Team |
| Temp help |

## Schedule

| ID | WBS | Task | Type | Duration | Start | Finish | Predecessors | Baseline start | Baseline finish | Baseline duration | Total slack | Free slack | Constraint | Resources | Work |
| --- | --- | --- | --- | --- | --- | --- | --- | --- | --- | --- | --- | --- | --- | --- | --- |
| 1 | 1 | **Materials for hubs** |  | 59d | 2005-10-10 | 2005-12-30 |  | 2005-10-10 | 2005-12-30 | 59d? | 0d |  |  |  | 1304h |
| 2 | 1.1 | Team decision on materials |  | 1d | 2005-10-10 | 2005-10-10 |  | 2005-10-10 | 2005-10-10 | 1d | 13d | 0d |  |  |  |
| 3 | 1.2 | PowerPoint template |  | 2d | 2005-10-11 | 2005-10-12 | 2 | 2005-10-11 | 2005-10-12 | 2d | 13d | 0d |  | Marsha | 16h |
| 4 | 1.3 | Boilerplate text |  | 3d | 2005-10-13 | 2005-10-17 | 3 | 2005-10-13 | 2005-10-17 | 3d | 13d | 0d |  | Marsha | 24h |
| 5 | 1.4 | Logos |  | 3d | 2005-10-18 | 2005-10-20 | 4 | 2005-10-18 | 2005-10-20 | 3d | 13d | 0d |  | Marsha | 24h |
| 6 | 1.5 | Style guide for hub materials |  | 7d | 2005-10-28 | 2005-11-07 |  | 2005-10-21 | 2005-10-31 | 7d | 8d | 0d | start no earlier than 2005-10-28 | Marsha | 56h |
| 7 | 1.6 | Revise newsletter |  | 14d | 2005-11-08 | 2005-11-25 | 6 |  |  |  | 25d |  |  | Marsha; Phil | 224h |
| 8 | 1.7 | Case studies |  | 30d | 2005-11-08 | 2005-12-19 | 6 | 2005-11-01 | 2005-12-12 | 30d | 9d |  |  | Marsha | 240h |
| 9 | 1.8 | Hub home page template |  | 10d | 2005-10-17 | 2005-10-28 |  | 2005-10-17 | 2005-10-28 | 10d | 32d | 30d | start no earlier than 2005-10-17 | Bob Wilkes | 80h |
| 10 | 1.9 | Demos |  | 40d | 2005-10-24 | 2005-12-16 |  | 2005-10-10 | 2005-12-23 | 55d | 10d |  | start no earlier than 2005-10-24 | Paul; Phil | 640h |
| 11 | 1.10 | Hub home page development |  | 10d | 2005-12-12 | 2005-12-23 | 9 | 2005-12-12 | 2005-12-23 | 10d | 2d | 0d | start no earlier than 2005-12-12 |  |  |
| 12 | 1.11 | Hub home page testing |  | 3d | 2005-12-26 | 2005-12-28 | 11 | 2005-12-26 | 2005-12-28 | 3d | 2d |  |  |  |  |
| 13 | 1.12 | Hub resource site live | milestone | 0d | 2005-12-30 | 2005-12-30 |  | 2005-12-30 | 2005-12-30 | 0d | 0d |  | start no earlier than 2005-12-30 | Bob Wilkes |  |
| 15 | 2 | **Branding strategy** |  | 11d | 2005-10-17 | 2005-10-31 |  |  |  |  | 43d |  |  |  | 88h |
| 16 | 2.1 | Branding strategy discussion |  | 1d | 2005-10-17 | 2005-10-17 |  |  |  |  | 43d | 0d | start no earlier than 2005-10-17 | Team | 8h |
| 17 | 2.2 | Logo revision |  | 3d | 2005-10-18 | 2005-10-20 | 16 |  |  |  | 43d | 0d | start no earlier than 2005-10-18 | Marsha | 24h |
| 18 | 2.3 | Tagline development |  | 5d | 2005-10-21 | 2005-10-27 | 17 |  |  |  | 43d | 0d |  | Marsha | 40h |
| 19 | 2.4 | Team approval |  | 2d | 2005-10-28 | 2005-10-31 | 18 |  |  |  | 43d | 0d |  | Phil | 16h |
| 20 | 2.5 | Post logos, taglines for hubs | milestone | 0d | 2005-10-31 | 2005-10-31 | 19 |  |  |  | 43d |  |  |  |  |
| 22 | 3 | **Web site updates** |  | 50d | 2005-10-17 | 2005-12-23 |  |  |  |  | 4d |  |  |  | 688h |
| 23 | 3.1 | iCampus home page - update content |  | 3d | 2005-10-17 | 2005-10-19 |  |  |  |  | 51d |  | start no earlier than 2005-10-17 | Temp help | 24h |
| 24 | 3.2 | iCampus home page - design revisions |  | 15d | 2005-10-17 | 2005-11-04 |  |  |  |  | 4d | 0d | start no earlier than 2005-10-17 | Bob Wilkes | 120h |
| 25 | 3.3 | and new content |  | 15d | 2005-11-07 | 2005-11-25 | 24 |  |  |  | 4d | 0d |  | Marsha | 120h |
| 26 | 3.4 | Review and testing |  | 10d | 2005-11-28 | 2005-12-09 | 25 |  |  |  | 14d | 0d |  | Team | 80h |
| 27 | 3.5 | Revised iCampus home page live | milestone | 0d | 2005-12-12 | 2005-12-12 | 26 |  |  |  | 14d |  | start no earlier than 2005-12-12 |  |  |
| 28 | 3.6 | Hub Outreach portal - update content |  | 3d | 2005-10-20 | 2005-10-24 |  |  |  |  | 48d |  | start no earlier than 2005-10-20 | Temp help | 24h |
| 29 | 3.7 | Hub Outreach portal - design revisions |  | 10d | 2005-11-07 | 2005-11-18 | 24 |  |  |  | 29d |  | start no earlier than 2005-11-07 | Bob Wilkes | 80h |
| 30 | 3.8 | and new content |  | 10d | 2005-11-28 | 2005-12-09 | 25 |  |  |  | 4d | 0d |  | Marsha; Phil | 160h |
| 31 | 3.9 | Review and testing |  | 10d | 2005-12-12 | 2005-12-23 | 30 |  |  |  | 4d |  |  | Team | 80h |
| 32 | 3.10 | Revised Outreach portal live | milestone | 0d | 2005-12-23 | 2005-12-23 |  |  |  |  | 4d |  | finish no earlier than 2005-12-23 |  |  |

Notes:
- 5: Logo variations will be specified in branding strategy
- 7: Revisit purpose, content, mailing list
- 9: for iCampus Outreach portal and for hub/affiliate use
- 13: This will be a password protected site with the above materials for hub/affiliate use.
- 20: Distribute when complete. Place on hub outreach/resources area when ready.

| ID | WBS | Task | Duration | Start | Finish | Predecessors | Total slack | Free slack | Constraint | Resources | Work |
| --- | --- | --- | --- | --- | --- | --- | --- | --- | --- | --- | --- |
| 34 | 4 | **Event - Capstone event** | 42d | 2005-10-10 | 2005-12-06 |  | 17d |  |  |  | 24h |
| 35 | 4.1 | Team decision on scope | 1d | 2005-10-10 | 2005-10-10 |  | 58d |  |  | Team | 8h |
| 36 | 4.2 | Kick off detailed planning | 2d | 2005-12-05 | 2005-12-06 |  | 17d |  | start no earlier than 2005-12-05 | Team | 16h |
| 38 | 5 | **MIT Museum** | 21d | 2005-10-10 | 2005-11-07 |  | 38d |  |  |  | 168h |
| 39 | 5.1 | Decisions on projects | 1d | 2005-10-10 | 2005-10-10 |  | 38d | 0d |  | Team | 8h |
| 40 | 5.2 | Planning with Pis | 10d | 2005-10-11 | 2005-10-24 | 39 | 38d | 0d |  | Elisabeth? | 80h |
| 41 | 5.3 | Communication/planning with Museum | 10d | 2005-10-25 | 2005-11-07 | 40 | 38d |  |  | Elisabeth? | 80h |
